# CSF Upgrades and Migrations

Schedule from MS Project, 2013-01-14 to 2013-06-14, A marks actual dates.
MIT

## Calendars

- Standard: Mon-Fri 08:00-12:00, 13:00-17:00; Sat-Sun off.

## Resources

| Resource |
| --- |
| Dave |
| René |
| Steve |
| Felicia |
| Ram |
| Kevin |
| Brian |
| Janet |
| Seth |
| Lee |
| Faith |
| Peter |
| Debra |

## Schedule

| ID | WBS | Task | Type | Duration | Start | Finish | Predecessors | Complete | Remaining | Baseline start | Baseline finish | Baseline duration | Total slack | Free slack | Resources | Work | Actual work |
| --- | --- | --- | --- | --- | --- | --- | --- | --- | --- | --- | --- | --- | --- | --- | --- | --- | --- |
| 1 | 1 | Upgrade CSF to 2.0 |  | 10d | 2013-01-14 A | 2013-01-25 A |  | 100% |  |  |  |  |  |  |  |  |  |
| 2 | 2 | **Upgrade of Existing CSF Apps to CSF 2.0** |  | 23d | 2013-02-13 A | 2013-03-15 |  | 96% | 1.02d | 2013-02-13 | 2013-03-08 | 18d? | 65d |  |  | 153.6h | 149.6h |
| 3 | 2.1 | **Development** |  | 11d | 2013-02-13 A | 2013-02-27 A |  | 100% |  | 2013-02-13 | 2013-03-08 | 18d |  |  |  | 64h | 64h |
| 4 | 2.1.1 | Upgrade IAP |  | 7d | 2013-02-14 A | 2013-02-25 A | 1FS+13d | 100% |  | 2013-02-14 | 2013-02-20 | 4d |  |  | Steve [50%] | 28h | 28h |
| 5 | 2.1.2 | Upgrade Subject Evaluation Report/OSE Report |  | 1d | 2013-02-26 A | 2013-02-26 A | 4FS+3d | 100% |  | 2013-02-26 | 2013-03-01 | 4d |  |  | Steve [50%] | 4h | 4h |
| 6 | 2.1.3 | Upgrade Sponsor Billing |  | 4d | 2013-02-13 A | 2013-02-19 A | 1FS+12d | 100% |  | 2013-02-13 | 2013-02-19 | 4d |  |  | Dave [50%] | 16h | 16h |
| 7 | 2.1.4 | Upgrade Survey Engine |  | 2d | 2013-02-26 A | 2013-02-27 A | 6FS+4d | 100% |  | 2013-02-26 | 2013-03-01 | 4d |  |  | Dave [50%] | 8h | 8h |
| 8 | 2.1.5 | Upgrade Response Rate Report |  | 2d | 2013-02-22 A | 2013-02-25 A | 7FS+1d | 100% |  | 2013-03-05 | 2013-03-08 | 4d |  |  | Dave [50%] | 8h | 8h |
| 9 | 2.1.6 | Upgrades complete | milestone | 0d | 2013-02-27 A | 2013-02-27 A | 4, 5, 6, 7, 8 | 100% |  | 2013-03-08 | 2013-03-08 | 0d |  |  | Dave [50%]; Steve [50%] |  |  |
| 10 | 2.2 | **Testing** |  | 18d | 2013-02-20 A | 2013-03-15 |  | 93% | 1.33d |  |  |  | 65d |  |  | 89.6h | 85.6h |
| 11 | 2.2.1 | **Test Planning** |  | 8d | 2013-02-20 A | 2013-03-01 A |  | 100% |  |  |  |  |  |  |  | 31.6h | 31.6h |
| 12 | 2.2.1.1 | Sponsor Billing |  | 3d | 2013-02-20 A | 2013-02-22 A | 4SS+4d | 100% |  |  |  |  |  |  | Seth [25%]; Faith [25%] | 7.6h | 7.6h |
| 13 | 2.2.1.2 | OSE Applications |  | 3d | 2013-02-27 A | 2013-03-01 A | 12FS+2d | 100% |  |  |  |  |  |  | Lee | 24h | 24h |
| 14 | 2.2.1.3 | Test Planning Complete | milestone | 0d | 2013-03-01 A | 2013-03-01 A | 12, 13 | 100% |  |  |  |  |  |  |  |  |  |
| 15 | 2.2.2 | **BA Testing** |  | 15d | 2013-02-25 A | 2013-03-15 |  | 88% | 1.76d |  |  |  | 65d |  |  | 58h | 54h |
| 16 | 2.2.2.1 | Sponsor Billing |  | 3d | 2013-02-25 A | 2013-02-27 A | 12 | 100% |  |  |  |  |  |  | Faith [25%] | 6h | 6h |
| 17 | 2.2.2.2 | IAP (includes planning) |  | 10d | 2013-03-04 A | 2013-03-15 | 16FS+2d | 80% | 2d |  |  |  | 65d | 0d | Seth [25%] | 20h | 16h |
| 18 | 2.2.2.3 | OSE Applications |  | 4d | 2013-03-04 A | 2013-03-07 A | 13 | 100% |  |  |  |  |  |  | Lee | 32h | 32h |
| 19 | 2.2.2.4 | BA Testing Complete | milestone | 0d | 2013-03-07 | 2013-03-07 | 16, 18 |  |  |  |  |  | 71d | 0d |  |  |  |
| 20 | 2.2.3 | **UAT** |  | 4d | 2013-03-04 A | 2013-03-07 A |  | 100% |  |  |  |  |  |  |  |  |  |
| 21 | 2.2.3.1 | OSE Applications |  | 4d | 2013-03-04 A | 2013-03-07 A | 18SS | 100% |  |  |  |  |  |  |  |  |  |
| 22 | 2.2.3.2 | UAT Complete | milestone | 0d | 2013-03-07 A | 2013-03-07 A | 21 | 100% |  |  |  |  |  |  |  |  |  |
| 23 | 2.2.4 | Testing Efforts Complete | milestone | 0d | 2013-03-07 | 2013-03-07 | 14, 19, 22 |  |  |  |  |  | 71d | 0d |  |  |  |
| 24 | 2.3 | **Deployment Preparation** |  | 0d | 2013-03-07 | 2013-03-07 |  |  |  |  |  |  | 71d |  |  |  |  |
| 25 | 2.3.1 | Get Eamon's approval to move apps to PROD | milestone | 0d | 2013-03-07 | 2013-03-07 | 23 |  |  |  |  |  | 71d |  | René |  |  |

| ID | WBS | Task | Type | Duration | Start | Finish | Predecessors | Complete | Remaining | Baseline start | Baseline finish | Baseline duration | Total slack | Free slack | Resources | Work | Actual work |
| --- | --- | --- | --- | --- | --- | --- | --- | --- | --- | --- | --- | --- | --- | --- | --- | --- | --- |
| 26 | 2.4 | **Go-live** |  | 12d | 2013-02-28 A | 2013-03-15 |  | 99% | 0d |  |  |  | 65d |  |  |  |  |
| 27 | 2.4.1 | Sponsor Billing | milestone | 1d | 2013-02-28 A | 2013-02-28 A | 16FS+2d | 100% |  |  |  |  |  |  |  |  |  |
| 28 | 2.4.2 | IAP | milestone | 0d | 2013-03-15 | 2013-03-15 | 17 |  |  |  |  |  | 65d | 0d |  |  |  |
| 29 | 2.4.3 | OSE Applications | milestone | 1d | 2013-03-07 A | 2013-03-08 A | 18, 21 | 100% |  |  |  |  |  |  |  |  |  |
| 30 | 2.5 | Upgrade of Existing CSF Apps to CSF 2.0 Complete | milestone | 0d | 2013-03-15 | 2013-03-15 | 27, 28, 29 |  |  |  |  |  | 65d |  |  |  |  |
| 31 | 3 | **Convert SAIS-Common Apps to CSF 2.0** |  | 1d? | 2013-01-14 | 2013-01-14 |  |  |  |  |  |  | 109d |  |  |  |  |
| 32 | 3.1 | Development |  | 1d? | 2013-01-14 | 2013-01-14 |  |  |  |  |  |  | 109d |  |  |  |  |
| 33 | 3.2 | Testing |  | 1d? | 2013-01-14 | 2013-01-14 |  |  |  |  |  |  | 109d |  |  |  |  |
| 34 | 4 | **PE REG Upgrade** |  | 57d? | 2013-01-14 A | 2013-04-02 |  | 67% | 19d? | 2013-02-07 | 2013-03-07 | 21d? | 53d |  |  | 266h | 216h |
| 35 | 4.1 | **Phase I - Java 6, Touchstone, and CSF Enabling** |  | 39d? | 2013-02-07 A | 2013-04-02 |  | 73% | 10.35d? | 2013-02-07 | 2013-03-07 | 21d? | 53d |  |  | 250h | 216h |
| 36 | 4.1.1 | **Development** |  | 27d | 2013-02-07 A | 2013-03-15 |  | 92% | 2.08d | 2013-02-07 | 2013-03-07 | 21d | 53d |  |  | 208h | 192h |
| 37 | 4.1.1.1 | Do set-up and configuration required for upgrade |  | 5d | 2013-02-07 A | 2013-02-13 A |  | 100% |  | 2013-02-07 | 2013-02-13 | 5d |  |  | Ram | 40h | 40h |
| 38 | 4.1.1.2 | Perform upgrade |  | 9d | 2013-02-14 A | 2013-02-27 A | 37 | 100% |  | 2013-02-14 | 2013-02-21 | 5d |  |  | Ram | 72h | 72h |
| 39 | 4.1.1.3 | Unit test changes |  | 12d | 2013-02-28 A | 2013-03-15 | 38 | 83% | 2d | 2013-02-22 | 2013-03-07 | 10d | 53d | 0d | Ram | 96h | 80h |
| 40 | 4.1.2 | **Testing** |  | 29d? | 2013-02-20 A | 2013-04-01 |  | 55% | 13.18d? |  |  |  | 54d |  |  | 42h | 24h |
| 41 | 4.1.2.1 | Test planning |  | 12d | 2013-02-20 A | 2013-03-07 A | 38SS+4d | 100% |  |  |  |  |  |  | Debra [25%] | 24h | 24h |
| 42 | 4.1.2.2 | QA testing |  | 5d | 2013-03-18 | 2013-03-22 | 41, 39 |  |  |  |  |  | 53d | 0d | Debra [25%] | 10h |  |
| 43 | 4.1.2.3 | QA bug fix testing |  | 3d | 2013-03-25 | 2013-03-27 | 42 |  |  |  |  |  | 53d | 0d | Debra [25%] | 6h |  |
| 44 | 4.1.2.4 | Load testing |  | 1d | 2013-03-21 | 2013-03-21 | 42FS-2d |  |  |  |  |  | 61d |  | Steve [25%] | 2h |  |
| 45 | 4.1.2.5 | User testing |  | 1d? | 2013-04-01 | 2013-04-01 | 43FS+2d |  |  |  |  |  | 53d | 0d |  |  |  |
| 46 | 4.1.3 | Go-live |  | 1d? | 2013-04-02 | 2013-04-02 | 45 |  |  |  |  |  | 53d | 0d |  |  |  |
| 47 | 4.2 | **Phase II - Full CSF Upgrade** |  | 47d? | 2013-01-14 | 2013-03-19 |  |  |  |  |  |  | 63d |  |  | 16h |  |
| 48 | 4.2.1 | **Development** |  | 2d? | 2013-03-18 | 2013-03-19 |  |  |  |  |  |  | 63d |  |  | 16h |  |
| 49 | 4.2.1.1 | Perform full upgrade |  | 1d? | 2013-03-18 | 2013-03-18 | 39 |  |  |  |  |  | 63d | 0d | Ram | 8h |  |
| 50 | 4.2.1.2 | Unit test changes |  | 1d? | 2013-03-19 | 2013-03-19 | 49 |  |  |  |  |  | 63d |  | Ram | 8h |  |

| ID | WBS | Task | Type | Duration | Start | Finish | Predecessors | Complete | Remaining | Baseline start | Baseline finish | Baseline duration | Total slack | Free slack | Constraint | Resources | Work | Actual work |
| --- | --- | --- | --- | --- | --- | --- | --- | --- | --- | --- | --- | --- | --- | --- | --- | --- | --- | --- |
| 51 | 4.2.2 | **Testing** |  | 1d? | 2013-01-14 | 2013-01-14 |  |  |  |  |  |  | 109d |  |  |  |  |  |
| 52 | 4.2.2.1 | QA |  | 1d? | 2013-01-14 | 2013-01-14 |  |  |  |  |  |  | 109d |  |  |  |  |  |
| 53 | 4.2.2.2 | User |  | 1d? | 2013-01-14 | 2013-01-14 |  |  |  |  |  |  | 109d |  |  |  |  |  |
| 54 | 4.2.3 | Go-live |  | 1d? | 2013-01-14 | 2013-01-14 |  |  |  |  |  |  | 109d | 56d |  |  |  |  |
| 55 | 4.3 | PE REG upgrade complete | milestone | 0d | 2013-04-02 | 2013-04-02 | 46, 54 |  |  |  |  |  | 53d |  |  | Ram |  |  |
| 56 | 5 | **OREG to Conversion to CSF 2.0** |  | 90d | 2013-02-11 A | 2013-06-14 |  | 23% | 68.94d | 2013-02-11 | 2013-05-28 | 76d | 0d |  |  |  | 662h | 176h |
| 57 | 5.1 | **Development (including unit testing)** |  | 35d | 2013-02-11 A | 2013-03-29 |  | 65% | 12.35d | 2013-02-11 | 2013-03-22 | 29d | 17d | 0d |  |  | 272h | 176h |
| 58 | 5.1.1 | Phase 1 - Required as-is , high priority (A/D and OREG) |  | 9d | 2013-02-11 A | 2013-02-22 A |  | 100% |  |  |  |  |  |  | start no earlier than 2013-02-11 | Felicia | 72h | 72h |
| 59 | 5.1.2 | Phase 2 - Medium priority validation and messaging |  | 15d | 2013-02-25 A | 2013-03-15 | 58 | 87% | 2d |  |  |  | 16d | 0d |  | Felicia | 120h | 104h |
| 60 | 5.1.3 | Phase 3 - Stabilize JAR and rafactor CSF dependencies |  | 5d | 2013-03-18 | 2013-03-22 | 59 |  |  |  |  |  | 16d | 0d |  | Felicia | 40h |  |
| 61 | 5.1.4 | Phase 4 - Modify OREG to use new JAR and upgrade to CSF 2.0 |  | 5d | 2013-03-25 | 2013-03-29 | 60 |  |  |  |  |  | 17d | 0d |  | Felicia | 40h |  |
| 62 | 5.1.5 | OREG conversion development complete | milestone | 0d | 2013-03-29 | 2013-03-29 | 61 |  |  |  |  |  | 17d | 0d |  | Felicia |  |  |
| 63 | 5.2 | Regression Testing |  | 24d | 2013-04-01 | 2013-05-03 | 62 |  |  | 2013-03-25 | 2013-04-26 | 24d | 17d | 0d |  | Kevin | 192h |  |
| 64 | 5.3 | UAT |  | 15d | 2013-04-29 | 2013-05-17 | 63FS-5d |  |  | 2013-04-29 | 2013-05-24 | 20d | 17d | 0d |  | Peter [25%] | 30h |  |
| 65 | 5.4 | **Deployment Preparation** |  | 11d | 2013-04-29 | 2013-05-13 |  |  |  |  |  |  | 24d |  |  |  | 88h |  |
| 66 | 5.4.1 | Create deployment plan |  | 5d | 2013-04-29 | 2013-05-03 | 64SS |  |  |  |  |  | 24d | 0d |  | René | 40h |  |
| 67 | 5.4.2 | Review deployment plan with participants |  | 1d | 2013-05-06 | 2013-05-06 | 66 |  |  |  |  |  | 24d | 0d |  | René | 8h |  |
| 68 | 5.4.3 | Create registration support plan |  | 5d | 2013-05-07 | 2013-05-13 | 67 |  |  |  |  |  | 24d |  |  | René | 40h |  |
| 69 | 5.5 | Go-live | milestone | 0d | 2013-05-21 | 2013-05-21 | 64FS+2d |  |  | 2013-05-28 | 2013-05-28 | 0d | 18d | 0d |  | René |  |  |
| 70 | 5.6 | Prod smoke test | milestone | 0d | 2013-05-21 | 2013-05-21 | 69 |  |  |  |  |  | 18d |  |  | Peter |  |  |
| 71 | 5.7 | Registration opens | milestone | 0d | 2013-06-03 | 2013-06-03 |  |  |  |  |  |  | 0d |  | start no earlier than 2013-06-03 | Peter |  |  |
| 72 | 5.8 | Registration support |  | 10d | 2013-06-03 | 2013-06-14 | 71 |  |  |  |  |  | 0d |  |  | René | 80h |  |
| 73 | 6 | **Notes Utility Beta** |  | 80d | 2013-02-25 A | 2013-06-14 |  |  | 80d |  |  |  | 0d |  |  |  | 496h |  |
| 74 | 6.1 | **Functional Specs** |  | 18.25d | 2013-02-25 A | 2013-03-21 |  |  | 18.25d |  |  |  | 24.75d |  |  |  | 146h |  |
| 75 | 6.1.1 | Write functional specs |  | 18d | 2013-02-25 A | 2013-03-20 |  |  | 18d |  |  |  | 24.75d | 0d |  | Seth | 144h |  |
| 76 | 6.1.2 | Have team review of functional specs |  | 0.25d | 2013-03-21 | 2013-03-21 | 75 |  |  |  |  |  | 24.75d | 0d |  | Seth | 2h |  |
| 77 | 6.1.3 | Send specs to sponsors for approval | milestone | 0d | 2013-03-21 | 2013-03-21 | 76 |  |  |  |  |  | 24.75d | 0d |  | Seth |  |  |
| 78 | 6.1.4 | Functional specs complete | milestone | 0d | 2013-03-21 | 2013-03-21 | 77 |  |  |  |  |  | 24.75d | 6.75d |  | Seth |  |  |
| 79 | 6.2 | Development |  | 19d | 2013-04-01 | 2013-04-26 | 57, 78 |  |  |  |  |  | 17d | 0d |  | Felicia | 152h |  |
| 80 | 6.3 | UAT |  | 15d | 2013-04-29 | 2013-05-17 | 79 |  |  |  |  |  | 17d | 0d |  | Peter [25%] | 30h |  |

| ID | WBS | Task | Type | Duration | Start | Finish | Predecessors | Total slack | Free slack | Constraint | Resources | Work |
| --- | --- | --- | --- | --- | --- | --- | --- | --- | --- | --- | --- | --- |
| 81 | 6.4 | **Deployment Preparation** |  | 11d | 2013-04-29 | 2013-05-13 |  | 24d |  |  |  | 88h |
| 82 | 6.4.1 | Create deployment plan |  | 5d | 2013-04-29 | 2013-05-03 | 66SS | 24d | 0d |  | René | 40h |
| 83 | 6.4.2 | Review deployment plan with participants |  | 1d | 2013-05-06 | 2013-05-06 | 82 | 24d | 0d |  | René | 8h |
| 84 | 6.4.3 | Create registration support plan |  | 5d | 2013-05-07 | 2013-05-13 | 83 | 24d |  |  | René | 40h |
| 85 | 6.5 | Go-live | milestone | 0d | 2013-05-21 | 2013-05-21 | 80FS+2d | 18d | 0d |  | René |  |
| 86 | 6.6 | Prod smoke test | milestone | 0d | 2013-05-21 | 2013-05-21 | 85 | 18d |  |  | Peter |  |
| 87 | 6.7 | Registration opens | milestone | 0d | 2013-06-03 | 2013-06-03 |  | 0d |  | start no earlier than 2013-06-03 | Peter |  |
| 88 | 6.8 | Registration support |  | 10d | 2013-06-03 | 2013-06-14 | 87 | 0d |  |  | René | 80h |
